Schedule from MS Project MPX, 2019-10-13 to 2019-11-28.

## Calendars

- Standard: Mon-Sun 08:00 am-12:00 pm, 01:00 pm-05:00 pm.

## Schedule

| ID | WBS | Task | Duration | Start | Finish | Predecessors |
| --- | --- | --- | --- | --- | --- | --- |
| 1 | 1 | CHL1 Tests (Oportunistic RF On) | 3d | 2019-10-18 | 2019-10-20 |  |
| 2 | 2 | Tunnel Open | 4d | 2019-10-18 | 2019-10-21 |  |
| 3 | 3 | HCO | 5d | 2019-10-21 | 2019-10-25 |  |
| 4 | 4 | SL RF On | 37d | 2019-10-23 | 2019-11-28 |  |
| 5 | 5 | 0L04 FE Test | 1d | 2019-10-24 | 2019-10-24 |  |
| 6 | 6 | **Injector Setup** | 24d | 2019-10-14 | 2019-11-06 |  |
| 7 | 6.1 | Gun Electrode 130 keV tests | 4d | 2019-10-18 | 2019-10-21 |  |
| 8 | 6.2 | FC1 | 2d | 2019-10-22 | 2019-10-23 | 7 |
| 9 | 6.3 | FC2 | 3d | 2019-10-24 | 2019-10-26 | 8 |
| 10 | 6.4 | ILD | 11d | 2019-10-27 | 2019-11-06 | 9 |
| 11 | 6.5 | **Other INJ Tests - Dates TBD** | 21d | 2019-10-14 | 2019-11-03 |  |
| 12 | 6.5.1 | Half Wave Plate Alignment | 1d | 2019-10-18 | 2019-10-18 |  |
| 13 | 6.5.2 | CREX Position Difference | 1d | 2019-10-18 | 2019-10-18 |  |
| 14 | 6.5.3 | Rotation Setup Saves for CREX | 1d | 2019-10-30 | 2019-10-30 |  |
| 15 | 6.5.4 | INJ Cycling Reproducibility | 4d | 2019-10-31 | 2019-11-03 |  |
| 16 | 6.5.5 | Beam Current Stability Tests | 1d | 2019-10-31 | 2019-10-31 |  |
| 17 | 6.5.6 | 4 Laser LLRF Phase Recovery | 1d | 2019-10-29 | 2019-10-29 |  |
| 18 | 6.5.7 | Spin Flip Method Investigation | 1d | 2019-10-29 | 2019-10-29 |  |
| 19 | 6.5.8 | RTP Transmission Time and 8 HV Measurments | 1d | 2019-10-14 | 2019-10-14 |  |
| 20 | 6.5.9 | RTP Measurments for PREX/CREX | 1d | 2019-10-14 | 2019-10-14 |  |
| 21 | 6.5.10 | FCup#2 Centering (Current Discrepency Investigation) | 1d | 2019-10-28 | 2019-10-28 |  |
| 22 | 7 | NL RF On | 34d | 2019-10-25 | 2019-11-27 |  |
| 23 | 8 | **5 pass Spin up** | 4d | 2019-11-07 | 2019-11-10 | 6 |
| 24 | 8.1 | **Cold Startup** | 2d | 2019-11-07 | 2019-11-08 |  |
| 25 | 8.1.1 | Beam to 1R | 1d | 2019-11-07 | 2019-11-07 |  |
| 26 | 8.1.2 | Beam to 2R | 1d | 2019-11-08 | 2019-11-08 | 25 |
| 27 | 8.1.3 | INJ Setup Tests (QA) - beam to 1R | 1d | 2019-11-07 | 2019-11-07 |  |

Notes:
- 5: http://devweb.acc.jlab.org/CSUEApps/atlis/task/18979
- 11: CIS and Injector Group to coordinate
- 12: http://opsweb.acc.jlab.org/CSUEApps/atlis/task/18799
- 13: http://opsweb.acc.jlab.org/CSUEApps/atlis/task/18793
- 14: http://opsweb.acc.jlab.org/CSUEApps/atlis/task/19670
- 15: AtLis still to be written
- 16: ATLis not yet written
- 17: More tests needed? / http://opsweb.acc.jlab.org/CSUEApps/atlis/task/19407
- 18: Wien Filter vs. Solenoid adjustments for CREX?
- 19: http://devweb.acc.jlab.org/CSUEApps/atlis/task/18789
- 20: http://devweb.acc.jlab.org/CSUEApps/atlis/task/19669
- 21: http://devweb.acc.jlab.org/CSUEApps/atlis/task/19617
- 25: Thread Beam Hand Phase Tune Energy Phaser
- 26: Thread through SL Hand Phase SL 2E Match SL Phaser
- 27: -Bunch Compression -Colinearity in Arcs -Ray Trace -Check Gang Phase vs. each laser. (checks relative timing of all 4 lasers). -Verify Inj->NL match

| ID | WBS | Task | Duration | Start | Finish | Predecessors |
| --- | --- | --- | --- | --- | --- | --- |
| 28 | 8.2 | **6 - ORFP ARC by ARC** | 4d | 2019-11-07 | 2019-11-10 |  |
| 29 | 8.2.1 | 6 - ARC4 | 1d | 2019-11-07 | 2019-11-07 |  |
| 30 | 8.2.2 | 7 - ARC7 | 1d | 2019-11-08 | 2019-11-08 | 29 |
| 31 | 8.2.3 | 8 - ARC9 | 1d | 2019-11-09 | 2019-11-09 | 30 |
| 32 | 8.2.4 | 9 - 5C | 1d | 2019-11-10 | 2019-11-10 | 31 |
| 33 | 9 | **Beam Tests to Halls - Dates TBD** | 8d | 2019-11-09 | 2019-11-16 |  |
| 34 | 9.1 | RF Stress Test | 2d | 2019-11-09 | 2019-11-10 |  |
| 35 | 9.2 | Spin Dance | 1d | 2019-11-11 | 2019-11-11 | 34 |
| 36 | 9.3 | Energy Adjustment + Spin Dance | 5d | 2019-11-12 | 2019-11-16 |  |
| 37 | 10 | **Ideas for BS - Dates TBD** | 44d | 2019-10-13 | 2019-11-25 |  |
| 38 | 10.1 | Match the Halls | 2d | 2019-11-17 | 2019-11-18 |  |
| 39 | 10.2 | SL Cryo/Electric Heat Balancing - Tief | 1d | 2019-11-19 | 2019-11-19 |  |
| 40 | 10.3 | C100-6R calibration | 1d | 2019-11-19 | 2019-11-19 |  |
| 41 | 10.4 | Wein Flip Method / Reproducibility | 1d | 2019-11-20 | 2019-11-20 |  |
| 42 | 10.5 | C100 Optics Effects | 1d | 2019-11-21 | 2019-11-21 |  |
| 43 | 10.6 | HD Current Accuracy | 1d | 2019-11-22 | 2019-11-22 |  |
| 44 | 10.7 | NL / SL Drift Box Supply Calibration | 1d | 2019-11-23 | 2019-11-23 |  |
| 45 | 10.8 | LEM Reproducibility | 1d | 2019-11-24 | 2019-11-24 |  |
| 46 | 10.9 | Optimimizing BLM/RF/IC Faults | 1d | 2019-11-25 | 2019-11-25 |  |
| 47 | 10.10 | Box Supply Cycling RHEL-7 (Cade) | 1d | 2019-10-13 | 2019-10-13 |  |
| 48 | 11 | Physics Start | 2d | 2019-11-26 | 2019-11-27 |  |

Notes:
- 33: Spin up 5 pass beam to Hall A. Spend 3 shifts max, optimizing RF and Beam transport with 600 kW in the Machine.
- 44: http://opsweb.acc.jlab.org/CSUEApps/atlis/task/16981 and http://opsweb.acc.jlab.org/CSUEApps/atlis/task/18319
- 46: Perhaps needed to be done during RF stress testing. / May also require re-calibration of BLM? BLMs too sensitive? BLM setup procedure attached to: http://opsweb.acc.jlab.org/CSUEApps/atlis/task/16634
- 47: http://opsweb.acc.jlab.org/CSUEApps/atlis/atlis.php?load=Task&task_id=19184
